# Contrat avec vidéo V1

Schedule from MS Project, 2004-03-15 to 2004-07-30, costs in €.
3MI

## Calendars

- Standard: Mon-Fri 08:00-12:00, 13:00-17:00; Sat-Sun off.

## Resources

| Resource | Group | Rate |
| --- | --- | --- |
| Chef de projet | Médiaformation | 120.36 |
| Scénariste | Sous-traitant | 100 |
| Auteur | Sous-traitant | 100 |
| Développeur informaticien | Mediaformation | 109.4 |
| Photographe | Sous-traitant | 60 |
| Infographiste | Mediaformation | 86.52 |
| Responsable de production | Mediaformation | 104.82 |
| Equipe Audio-vidéo | Sous-traitant | 700 |
| Frais de déplacement | Mediaformation |  |

## Schedule

| ID | WBS | Task | Duration | Start | Finish | Predecessors | Total slack | Resources | Work | Cost |
| --- | --- | --- | --- | --- | --- | --- | --- | --- | --- | --- |
| 1 | 1 | **CONTRAT avec Vidéo** | 100d | 2004-03-15 | 2004-07-30 |  | 0d |  | 832h | 101,849.76 |
| 2 | 1.1 | Repérer, extraire (besoins, pbs, désirs,…) à partir des entretiens qualitatifs | 10d | 2004-03-15 | 2004-03-26 |  | 0d | Chef de projet [50%]; Frais de déplacement | 40h | 5,814.4 |
| 3 | 1.2 | Modéliser les contenus | 15d | 2004-03-29 | 2004-04-16 | 2 | 0d | Auteur [66.7%]; Responsable de production [13.3%] | 96h | 9,677.12 |
| 4 | 1.3 | Scénariser le programme de formation | 10d | 2004-04-19 | 2004-04-30 | 3 | 0d | Scénariste [70%]; Chef de projet [10%] | 64h | 6,562.88 |
| 5 | 1.4 | **Produire le programme** | 40d | 2004-05-03 | 2004-06-25 |  | 0d |  | 408h | 54,869.76 |
| 6 | 1.4.1 | Rédiger les textes | 10d | 2004-05-03 | 2004-05-14 | 4 | 10d | Auteur [80%] | 64h | 6,400 |
| 7 | 1.4.2 | Réaliser les photographies | 5d | 2004-05-03 | 2004-05-07 | 4 | 15d | Photographe [80%] | 32h | 1,920 |
| 8 | 1.4.3 | Dessiner les illustrations | 10d | 2004-05-03 | 2004-05-14 | 4 | 10d | Infographiste [80%]; Responsable de production [20%] | 80h | 7,214.4 |
| 9 | 1.4.4 | Réaliser le montage informatique | 20d | 2004-05-31 | 2004-06-25 | 6, 7, 8, 11 | 0d | Développeur informaticien [40%]; Responsable de production [20%] | 96h | 10,355.84 |
| 10 | 1.4.5 | Développer le dispositif d'utilisation du programme | 20d | 2004-05-03 | 2004-05-28 | 4 | 45d | Développeur informaticien [60%]; Responsable de production [10%] | 112h | 12,179.52 |
| 11 | 1.4.6 | Réaliser les séquences audio-vidéo | 20d | 2004-05-03 | 2004-05-28 | 4 | 0d | Equipe Audio-vidéo [15%] | 24h | 16,800 |
| 12 | 1.5 | **Evaluer le programme** | 25d | 2004-06-28 | 2004-07-30 |  | 0d |  | 184h | 20,111.2 |
| 13 | 1.5.1 | Réaliser le test alpha | 5d | 2004-06-28 | 2004-07-02 | 9, 11 | 0d | Responsable de production [40%]; Développeur informaticien [40%]; Infographiste [40%] | 48h | 4,811.84 |
| 14 | 1.5.2 | Apporter les corrections suite au test alpha | 5d | 2004-07-05 | 2004-07-09 | 13 | 0d | Développeur informaticien [40%]; Infographiste [40%] | 32h | 3,134.72 |
| 15 | 1.5.3 | Réaliser le test Bèta | 10d | 2004-07-12 | 2004-07-23 | 14 | 0d | Chef de projet [30%]; Responsable de production [30%]; Développeur informaticien [30%]; Frais de déplacement | 72h | 9,029.92 |
| 16 | 1.5.4 | Apporter les corrections suite au test Béta | 5d | 2004-07-26 | 2004-07-30 | 15 | 0d | Développeur informaticien [40%]; Infographiste [40%] | 32h | 3,134.72 |
| 17 | 1.6 | Manager le projet (5% du travail total de la main d'œuvre) | 80d | 2004-03-15 | 2004-07-02 |  | 20d | Chef de projet [6.2%] | 40h | 4,814.4 |
