# Contrat avec vidéo V1

Schedule from MS Project, 2004-03-15 to 2004-07-02, costs in €.
3MI

## Calendars

- Standard: Mon-Fri 08:00-12:00, 13:00-17:00; Sat-Sun off.

## Resources

| Resource | Group | Rate |
| --- | --- | --- |
| Chef de projet | Médiaformation | 67.85 |
| Scénariste | Sous-traitant | 100 |
| Auteur | Sous-traitant | 100 |
| Développeur informaticien | Mediaformation | 65.85 |
| Photographe | Sous-traitant | 60 |
| Infographiste | Mediaformation | 49.71 |
| Responsable de production | Mediaformation | 54.12 |
| Réalisateur Audio-vidéo | Sous-traitant |  |
| Frais de déplacement | Mediaformation |  |

## Schedule

| ID | WBS | Task | Duration | Start | Finish | Predecessors | Total slack | Resources | Work | Cost |
| --- | --- | --- | --- | --- | --- | --- | --- | --- | --- | --- |
| 1 | 1 | **CONTRAT sans Vidéo** | 80d | 2004-03-15 | 2004-07-02 |  | 0d |  | 808h | 58,858.32 |
| 2 | 1.1 | Repérer, extraire (besoins, pbs, désirs,…) à partir des entretiens qualitatifs | 10d | 2004-03-15 | 2004-03-26 |  | 0d | Chef de projet [50%]; Frais de déplacement | 40h | 3,714 |
| 3 | 1.2 | Modéliser les contenus | 15d | 2004-03-29 | 2004-04-16 | 2 | 0d | Auteur [66.7%]; Responsable de production [13.3%] | 96h | 8,865.92 |
| 4 | 1.3 | Scénariser le programme de formation | 10d | 2004-04-19 | 2004-04-30 | 3 | 0d | Scénariste [70%]; Chef de projet [10%] | 64h | 6,142.8 |
| 5 | 1.4 | **Produire le programme** | 20d | 2004-05-03 | 2004-05-28 |  | 0d |  | 384h | 25,501.12 |
| 6 | 1.4.1 | Rédiger les textes | 10d | 2004-05-03 | 2004-05-14 | 4 | 0d | Auteur [80%] | 64h | 6,400 |
| 7 | 1.4.2 | Réaliser les photographies | 5d | 2004-05-03 | 2004-05-07 | 4 | 5d | Photographe [80%] | 32h | 1,920 |
| 8 | 1.4.3 | Dessiner les illustrations | 10d | 2004-05-03 | 2004-05-14 | 4 | 0d | Infographiste [80%]; Responsable de production [20%] | 80h | 4,047.36 |
| 9 | 1.4.4 | Réaliser le montage informatique | 10d | 2004-05-17 | 2004-05-28 | 6, 7, 8 | 0d | Développeur informaticien [80%]; Responsable de production [40%] | 96h | 5,946.24 |
| 10 | 1.4.5 | Développer le dispositif d'utilisation du programme | 20d | 2004-05-03 | 2004-05-28 | 4 | 25d | Développeur informaticien [60%]; Responsable de production [10%] | 112h | 7,187.52 |
| 11 | 1.5 | **Evaluer le programme** | 25d | 2004-05-31 | 2004-07-02 |  | 0d |  | 184h | 11,920.48 |
| 12 | 1.5.1 | Réaliser le test alpha | 5d | 2004-05-31 | 2004-06-04 | 9 | 0d | Responsable de production [40%]; Développeur informaticien [40%]; Infographiste [40%] | 48h | 2,714.88 |
| 13 | 1.5.2 | Apporter les corrections suite au test alpha | 5d | 2004-06-07 | 2004-06-11 | 12 | 0d | Développeur informaticien [40%]; Infographiste [40%] | 32h | 1,848.96 |
| 14 | 1.5.3 | Réaliser le test Bèta | 10d | 2004-06-14 | 2004-06-25 | 13 | 0d | Chef de projet [30%]; Responsable de production [30%]; Développeur informaticien [30%]; Frais de déplacement | 72h | 5,507.68 |
| 15 | 1.5.4 | Apporter les corrections suite au test Béta | 5d | 2004-06-28 | 2004-07-02 | 14 | 0d | Développeur informaticien [40%]; Infographiste [40%] | 32h | 1,848.96 |
| 16 | 1.6 | Manager le projet (5% du travail total de la main d'œuvre) | 80d | 2004-03-15 | 2004-07-02 |  | 0d | Chef de projet [6.2%] | 40h | 2,714 |
